# ERS Communications & Training Plan

Schedule from MS Project, 2005-05-12 to 2006-02-28, A marks actual dates.
UCOP

## Calendars

- Standard: Mon-Fri 08:00-12:00, 13:00-17:00; Sat-Sun off.

## Resources

| Resource |
| --- |
| Mgmt |
| Deb |
| Campuses |
| UCOP |
| Mgmt. |
| Davis |
| David |

## Schedule

| ID | WBS | Task | Type | Duration | Start | Finish | Complete | Total slack | Constraint | Resources | Work | Actual work |
| --- | --- | --- | --- | --- | --- | --- | --- | --- | --- | --- | --- | --- |
| 1 | 1 | **Start Up Phase** |  | 20d | 2005-05-12 A | 2005-06-08 A | 100% |  |  |  | 480h | 480h |
| 2 | 1.1 | Orient and familiarize |  | 20d | 2005-05-12 A | 2005-06-08 A | 100% |  |  | Deb | 160h | 160h |
| 3 | 1.2 | Prepare Project Plan |  | 20d | 2005-05-12 A | 2005-06-08 A | 100% |  |  | Deb | 160h | 160h |
| 4 | 1.3 | Prepare Kick-Off Materials |  | 20d | 2005-05-12 A | 2005-06-08 A | 100% |  |  | Deb | 160h | 160h |
| 5 | 2 | Deliver Project Plan | milestone | 0d | 2005-06-08 A | 2005-06-08 A | 100% |  | finish no earlier than 2005-06-08 | Deb |  |  |
| 6 | 3 | Deliver Kick-Off Materials | milestone | 0d | 2005-06-08 A | 2005-06-08 A | 100% |  | finish no earlier than 2005-06-08 | Deb |  |  |
| 7 | 4 | Start Up Phase Complete | milestone | 0d | 2005-06-08 A | 2005-06-08 A | 100% |  | finish no earlier than 2005-06-08 |  |  |  |
| 9 | 5 | **Assess Phase** |  | 20d? | 2005-06-09 A | 2005-07-06 A | 100% |  |  |  | 1648h | 1648h |
| 10 | 5.1 | Confirm Needs |  | 20d | 2005-06-09 A | 2005-07-06 A | 100% |  | start no earlier than 2005-06-09 | Deb | 160h | 160h |
| 11 | 5.2 | Confirm identified audiences |  | 20d? | 2005-06-09 A | 2005-07-06 A | 100% |  | start no earlier than 2005-06-09 | Deb | 160h | 160h |
| 12 | 5.3 | Identify performance criteria for training audiences |  | 20d | 2005-06-09 A | 2005-07-06 A | 100% |  | start no earlier than 2005-06-09 | Deb; Campuses | 320h | 320h |
| 13 | 5.4 | Confirm content required |  | 18d | 2005-06-13 A | 2005-07-06 A | 100% |  | start no earlier than 2005-06-13 | Deb; Campuses | 288h | 288h |
| 14 | 5.5 | Confirm appropriate delivery mechanism(s) |  | 18d | 2005-06-13 A | 2005-07-06 A | 100% |  | start no earlier than 2005-06-13 | Deb | 144h | 144h |
| 15 | 5.6 | Document Communications Strategy |  | 18d | 2005-06-13 A | 2005-07-06 A | 100% |  | start no earlier than 2005-06-13 | Deb | 144h | 144h |
| 16 | 5.7 | Document Training Strategy |  | 18d | 2005-06-13 A | 2005-07-06 A | 100% |  | start no earlier than 2005-06-13 | Deb | 144h | 144h |
| 17 | 5.8 | Assess Macromedia Breeze and other training delivery mechanisms |  | 18d | 2005-06-13 A | 2005-07-06 A | 100% |  | start no earlier than 2005-06-13 | Deb | 144h | 144h |
| 18 | 5.9 | Obtain Macromedia Breeze |  | 18d | 2005-06-13 A | 2005-07-06 A | 100% |  | finish no earlier than 2005-07-06 | UCOP | 144h | 144h |
| 19 | 6 | Submit Findings to Management Group | milestone | 0d | 2005-07-06 A | 2005-07-06 A | 100% |  | finish no earlier than 2005-07-06 | Deb |  |  |
| 20 | 7 | Management group sign-off | milestone | 0d | 2005-07-13 A | 2005-07-13 A | 100% |  | finish no earlier than 2005-07-13 | Mgmt |  |  |
| 21 | 8 | Assess Phase Complete | milestone | 0d | 2005-07-13 A | 2005-07-13 A | 100% |  | finish no earlier than 2005-07-13 |  |  |  |
| 23 | 9 | **Design Phase** |  | 18d | 2005-07-13 A | 2005-08-05 A | 100% |  |  |  | 432h | 432h |
| 24 | 9.1 | Design communications |  | 18d | 2005-07-13 A | 2005-08-05 A | 100% |  | finish no earlier than 2005-08-05 | Deb | 144h | 144h |
| 25 | 9.2 | Design training core content |  | 18d | 2005-07-13 A | 2005-08-05 A | 100% |  | finish no earlier than 2005-08-05 | Deb | 144h | 144h |
| 26 | 9.3 | Document Design |  | 18d | 2005-07-13 A | 2005-08-05 A | 100% |  | finish no earlier than 2005-08-05 | Deb | 144h | 144h |
| 27 | 10 | Submit Design Documentation to Management Group | milestone | 0d | 2005-08-05 A | 2005-08-05 A | 100% |  | finish no earlier than 2005-08-05 | Deb |  |  |
| 28 | 11 | Management Group sign-off | milestone | 0d | 2005-08-10 | 2005-08-10 |  | 143d | finish no earlier than 2005-08-10 | Mgmt |  |  |
| 29 | 12 | Design Phase Complete | milestone | 0d | 2005-08-10 | 2005-08-10 |  | 143d | finish no earlier than 2005-08-10 |  |  |  |

| ID | WBS | Task | Type | Duration | Start | Finish | Predecessors | Complete | Remaining | Total slack | Free slack | Constraint | Resources | Work | Actual work |
| --- | --- | --- | --- | --- | --- | --- | --- | --- | --- | --- | --- | --- | --- | --- | --- |
| 31 | 13 | **Development Phase** |  | 168d? | 2005-05-12 A | 2006-01-02 |  | 70% | 50.4d? | 40d |  |  |  | 1360h | 952h |
| 32 | 13.1 | **Develop Communications** |  | 168d? | 2005-05-12 A | 2006-01-02 |  | 73% | 46.1d? | 40d |  |  |  | 1312h | 952h |
| 33 | 13.1.1 | Commitment Phase Communications |  | 20d? | 2005-05-12 A | 2005-06-08 A |  | 100% |  |  |  | start no earlier than 2005-05-12 | Deb | 160h | 160h |
| 34 | 13.1.2 | Orientation Phase Communications |  | 49d? | 2005-06-08 A | 2005-08-15 A |  | 100% |  |  |  | finish no earlier than 2005-08-15 | Deb | 392h | 392h |
| 35 | 13.1.3 | Preparation Phase Communications |  | 25d? | 2005-08-01 A | 2005-09-02 A |  | 100% |  |  |  | finish no earlier than 2005-09-02 | Deb | 200h | 200h |
| 36 | 13.1.4 | Planning Phase Communications |  | 25d? | 2005-09-05 A | 2005-10-07 A |  | 100% |  |  |  | finish no earlier than 2005-10-07 | Deb | 200h | 200h |
| 37 | 13.1.5 | Implementation Phase Communications |  | 45d? | 2005-11-01 | 2006-01-02 |  |  |  | 40d |  | finish no earlier than 2006-01-02 | Deb | 360h |  |
| 38 | 13.2 | Work Product Review |  | 6d | 2005-10-05 | 2005-10-12 |  |  |  | 98d |  | finish no earlier than 2005-10-12 | Mgmt | 48h |  |
| 39 | 14 | Management Group sign-off | milestone | 0d | 2005-10-12 | 2005-10-12 |  |  |  | 99d |  | start no earlier than 2005-10-12 | Mgmt |  |  |
| 40 | 15 | Development Phase Complete | milestone | 0d | 2006-01-02 | 2006-01-02 |  |  |  | 40d |  | finish no earlier than 2006-01-02 |  |  |  |
| 42 | 16 | **PilotTraining Phase** |  | 53d? | 2005-10-04 A | 2005-12-15 |  |  | 53d? | 52d |  |  |  | 1200h |  |
| 43 | 16.1 | **Communications** |  | 50d? | 2005-10-04 A | 2005-12-12 |  |  | 50d? | 55d |  |  |  |  |  |
| 44 | 16.1.1 | Deliver Communication materials to Radhika | milestone | 0d | 2005-10-04 A | 2005-10-04 A |  | 100% |  |  |  | start no earlier than 2005-10-04 |  |  |  |
| 45 | 16.1.2 | Feedback and revisions |  | 3d | 2005-10-05 | 2005-10-07 | 44 |  |  | 55d | 0d | start no earlier than 2005-10-05 |  |  |  |
| 46 | 16.1.3 | Campus feedback on communications |  | 46d? | 2005-10-10 | 2005-12-12 | 45 |  |  | 55d |  | start no earlier than 2005-10-10 |  |  |  |
| 47 | 16.2 | **Training Materials** |  | 45d? | 2005-10-14 | 2005-12-15 |  |  |  | 52d |  |  | Deb; Davis | 1200h |  |
| 48 | 16.2.1 | Working draft to Lia - 1st round | milestone | 0d | 2005-10-14 | 2005-10-14 |  |  |  | 97d |  | start no earlier than 2005-10-14 |  |  |  |
| 49 | 16.2.2 | Woring draft to Lia - 2nd round | milestone | 0d | 2005-10-21 | 2005-10-21 |  |  |  | 92d |  | start no earlier than 2005-10-21 |  |  |  |
| 50 | 16.2.3 | Working draft to Lia - 3rd round | milestone | 0d | 2005-10-28 | 2005-10-28 |  |  |  | 87d |  | start no earlier than 2005-10-28 |  |  |  |
| 51 | 16.2.4 | Deliver Pilot Training Materials to Project Team | milestone | 0d | 2005-10-31 | 2005-10-31 |  |  |  | 86d |  | start no earlier than 2005-10-31 | Deb; Davis |  |  |
| 52 | 16.2.5 | Feedback from Project Team on training materials | milestone | 0d | 2005-11-02 | 2005-11-02 |  |  |  | 84d |  | start no earlier than 2005-11-02 |  |  |  |
| 53 | 16.2.6 | Materials to Campus Functional Work Group and UC Davis ERS Review Group | milestone | 0d | 2005-11-04 | 2005-11-04 |  |  |  | 52d | 0d | start no earlier than 2005-11-04 |  |  |  |
| 54 | 16.2.7 | Use and review training product |  | 29d? | 2005-11-07 | 2005-12-15 | 53 |  |  | 52d |  | start no earlier than 2005-11-07 |  |  |  |
| 55 | 16.2.8 | Feedback from Davis Pilot Groups - ongoing |  | 30d | 2005-11-04 | 2005-12-15 | 53 |  |  | 52d |  | start no earlier than 2005-11-04 |  |  |  |
| 56 | 16.2.9 | Revise training materials if appropriate |  | 22d | 2005-11-16 | 2005-12-15 |  |  |  | 52d |  | start no earlier than 2005-11-16 | Deb | 176h |  |
| 57 | 16.2.10 | Re-pilot revised materials if necessary |  | 19d? | 2005-11-16 | 2005-12-12 |  |  |  | 55d | 0d | finish no earlier than 2005-12-12 | Deb; Davis | 304h |  |
| 58 | 17 | Pilot Phase Complete | milestone | 0d | 2005-12-12 | 2005-12-12 | 57 |  |  | 55d |  | start no earlier than 2005-11-22 |  |  |  |

| ID | WBS | Task | Type | Duration | Start | Finish | Total slack | Constraint | Resources | Work |
| --- | --- | --- | --- | --- | --- | --- | --- | --- | --- | --- |
| 60 | 18 | **Deployment Phase** |  | 86d? | 2005-10-14 | 2006-02-10 | 11d |  |  | 192h |
| 61 | 18.1 | Commitment Phase Communications | milestone | 0d | 2005-10-14 | 2005-10-14 | 96d | finish no earlier than 2005-10-14 | Deb |  |
| 62 | 18.2 | Orientation Phase Communications | milestone | 0d | 2005-10-14 | 2005-10-14 | 96d | finish no earlier than 2005-10-14 | Deb |  |
| 63 | 18.3 | Planning Phase Communications | milestone | 0d? | 2005-10-14 | 2005-10-14 | 97d | start no earlier than 2005-10-14 | Deb |  |
| 64 | 18.4 | Preparation Phase Communications | milestone | 0d? | 2005-10-14 | 2005-10-14 | 96d | finish no earlier than 2005-10-14 | Deb |  |
| 65 | 18.5 | Implementatoin Phase Communications | milestone | 0d | 2006-01-02 | 2006-01-02 | 41d | start no earlier than 2006-01-02 | Deb |  |
| 66 | 18.6 | Core Training Materials Release | milestone | 0d | 2006-01-02 | 2006-01-02 | 41d | start no earlier than 2006-01-02 | Deb |  |
| 67 | 18.7 | Train the Trainers |  | 7d | 2006-01-10 | 2006-01-18 | 28d | finish no earlier than 2006-01-18 | Deb | 56h |
| 68 | 18.8 | Support Campus Training Efforts |  | 17d? | 2006-01-19 | 2006-02-10 | 11d | finish no earlier than 2006-02-10 | Deb | 136h |
| 69 | 19 | Deployment Phase Complete | milestone | 0d | 2006-02-28 | 2006-02-28 | 0d | start no earlier than 2006-02-28 |  |  |
